# BB-09 - met betonskelet

Schedule from MS Project, 2003-01-12 to 2003-01-31, status date 2003-01-08.
BAM Nelissen Van Egteren

## Calendars

- ALLEEN WERKDAGEN: Mon-Fri 08:30-12:30, 13:00-17:00; Sat-Sun off. Exceptions (off unless hours are given): 2003-01-11 to 2003-01-12 08:30-12:30, 13:00-17:00, 2003-01-18 to 2003-01-19 08:30-12:30, 13:00-17:00, 2003-01-25 to 2003-01-26 08:30-12:30, 13:00-17:00.

## Schedule

| ID | WBS | Task | Type | Duration | Start | Finish | Predecessors | Total slack |
| --- | --- | --- | --- | --- | --- | --- | --- | --- |
| 1 | 1 | **BOVENBOUWFASE** |  | 20d | 2003-01-12 | 2003-01-31 |  | 0d |
| 2 | 1.1 | betonkolommen kist+wap+beton |  | 5d | 2003-01-12 | 2003-01-16 |  | 0d |
| 3 | 1.2 | dakvloer ondersteuning/bekisting |  | 5d | 2003-01-16 | 2003-01-20 | 2SS+4d | 0d |
| 4 | 1.3 | dakvloer breedplaat/wapening |  | 5d | 2003-01-19 | 2003-01-23 | 3SS+3d | 0d |
| 5 | 1.4 | dakvloer beton storten |  | 1d | 2003-01-24 | 2003-01-24 | 4SS+5d | 0d |
| 6 | 1.5 | dakvloer verhardingstijd |  | 5d | 2003-01-25 | 2003-01-29 | 5SS+1d | 0d |
| 7 | 1.6 | dakvloer ontkisten |  | 2d | 2003-01-30 | 2003-01-31 | 6SS+5d | 0d |
| 8 | 1.7 | start gevel/dak fase | milestone | 0d | 2003-01-31 | 2003-01-31 | 7SS+2d | 0d |
